# Erstellung einer Website

Schedule from MS Project, 2008-06-17 to 2008-07-29, costs in €.
Der neue Internetauftritt der Project Consulting
Beginn: 2004-03-01

## Calendars

- Standard: Mon-Fri 08:00-12:00, 13:00-17:00; Sat-Sun off.

## Resources

| Resource | Group | Rate |
| --- | --- | --- |
| Matthias Jäger | Programmierer | 100 |
| Steffen Reister | Graphiker | 100 |
| Renke Holert | Consultant | 100 |
| Ralph Goetze | Netzwerk Spezialist | 100 |
| Team C# |  |  |

## Schedule

| ID | WBS | Task | Type | Duration | Start | Finish | Predecessors | Baseline start | Baseline finish | Baseline duration | Total slack | Resources | Work | Cost | Baseline cost |
| --- | --- | --- | --- | --- | --- | --- | --- | --- | --- | --- | --- | --- | --- | --- | --- |
| 1 | 1 | **Meilensteine** |  | 30.5d | 2008-06-17 | 2008-07-29 |  |  |  |  | 0d |  |  |  |  |
| 2 | 1.1 | Auftrag erteilt | milestone | 0d | 2008-06-17 | 2008-06-17 |  | 2002-07-01 | 2002-07-01 | 0d | 0d |  |  |  |  |
| 3 | 1.2 | Abnahme Prototyp | milestone | 0d | 2008-06-26 | 2008-06-26 | 8 | 2002-07-10 | 2002-07-10 | 0d | 0d |  |  |  |  |
| 4 | 1.3 | Website erstellt | milestone | 0d | 2008-07-23 | 2008-07-23 | 14 | 2002-08-02 | 2002-08-02 | 0d | 0d |  |  |  |  |
| 5 | 1.4 | Projektabschluss | milestone | 0d | 2008-07-29 | 2008-07-29 | 18 | 2002-08-08 | 2002-08-08 | 0d | 0d |  |  |  |  |
| 6 | 2 | **Initialisierung** |  | 2d | 2008-06-17 | 2008-06-18 | 2 | 2002-07-01 | 2002-07-02 | 2d | 0d |  | 16h | 1,600 | 1,600 |
| 7 | 2.1 | Marketingkonzept erstellen |  | 2d | 2008-06-17 | 2008-06-18 |  | 2002-07-01 | 2002-07-02 | 2d | 0d | Steffen Reister | 16h | 1,600 | 1,600 |
| 8 | 3 | **Entwurf Prototyp** |  | 6d | 2008-06-19 | 2008-06-26 | 6 | 2002-07-03 | 2002-07-10 | 6d | 0d |  | 56h | 5,600 | 5,600 |
| 9 | 3.1 | Designkonzept |  | 2d | 2008-06-19 | 2008-06-20 |  | 2002-07-03 | 2002-07-04 | 2d | 0d | Ralph Goetze | 16h | 1,600 | 1,600 |
| 10 | 3.2 | Navigationskonzept |  | 2d | 2008-06-23 | 2008-06-24 | 9 | 2002-07-05 | 2002-07-08 | 2d | 0d | Renke Holert | 16h | 1,600 | 1,600 |
| 11 | 3.3 | Implementationskonzept |  | 1d | 2008-06-25 | 2008-06-25 | 10 | 2002-07-09 | 2002-07-09 | 1d | 0d | Matthias Jäger | 8h | 800 | 800 |
| 12 | 3.4 | Betriebskonzept |  | 1d | 2008-06-25 | 2008-06-25 | 11SS | 2002-07-09 | 2002-07-09 | 1d | 0d | Steffen Reister | 8h | 800 | 800 |
| 13 | 3.5 | Konzeptpräsentation |  | 1d | 2008-06-26 | 2008-06-26 | 12, 11 | 2002-07-10 | 2002-07-10 | 1d | 0d | Steffen Reister | 8h | 800 | 800 |
| 14 | 4 | **Realisierung** |  | 19d | 2008-06-27 | 2008-07-23 | 3 | 2002-07-11 | 2002-08-02 | 17d | 0d |  | 576h | 57,600 | 47,200 |
| 15 | 4.1 | ToDo Liste erstellen |  | 1d | 2008-06-27 | 2008-06-27 |  | 2002-07-11 | 2002-07-11 | 1d | 0d | Steffen Reister | 8h | 800 | 800 |
| 16 | 4.2 | Inhalte erstellen |  | 13d | 2008-06-30 | 2008-07-16 | 15 | 2002-07-12 | 2002-08-01 | 15d | 5d | Ralph Goetze; Matthias Jäger | 208h | 20,800 | 36,000 |
| 17 | 4.3 | Programmierung |  | 15d | 2008-07-03 | 2008-07-23 | 15FS+3d | 2002-07-17 | 2002-08-02 | 13d | 0d | Renke Holert; Steffen Reister; Matthias Jäger | 360h | 36,000 | 10,400 |
| 18 | 5 | **Abnahme** |  | 3.5d | 2008-07-24 | 2008-07-29 | 4 | 2002-08-05 | 2002-08-08 | 3.5d | 0d |  | 28h | 2,800 | 3,600 |
| 19 | 5.1 | Abnahmedokument |  | 1d | 2008-07-24 | 2008-07-24 |  | 2002-08-05 | 2002-08-05 | 1d | 0d | Ralph Goetze | 8h | 800 | 800 |
| 20 | 5.2 | Testlauf |  | 1d | 2008-07-25 | 2008-07-25 | 19 | 2002-08-06 | 2002-08-06 | 1d | 0d | Matthias Jäger | 8h | 800 | 1,600 |
| 21 | 5.3 | Fehlerbehebung |  | 1d | 2008-07-28 | 2008-07-28 | 20 | 2002-08-07 | 2002-08-07 | 1d | 0d | Renke Holert | 8h | 800 | 800 |
| 22 | 5.4 | Liveschaltung der Website |  | 0.5d | 2008-07-29 | 2008-07-29 | 21 | 2002-08-08 | 2002-08-08 | 0.5d | 0d | Renke Holert | 4h | 400 | 400 |
